# Renusagar Schedule_3.1.2022

Schedule from MS Project, 2021-10-25 to 2023-07-31, 10 hours a day.

## Calendars

- RNSG 5 X 10 Hrs: Mon-Fri 08:00-12:00, 13:00-17:00; Sat-Sun off.
- RNSG 6 days *10: Mon-Sat 08:00-13:00, 14:00-19:00; Sun off.

## Schedule

| ID | WBS | Task | Type | Duration | Start | Finish | Predecessors | Baseline start | Baseline finish | Baseline duration | Total slack | Free slack | Planned % Complete | WLG Drg |
| --- | --- | --- | --- | --- | --- | --- | --- | --- | --- | --- | --- | --- | --- | --- |
| 1 | 1 | **Engineering Inputs** |  | 144d | 2021-10-25 | 2022-07-01 |  | 2021-10-25 | 2022-07-07 | 147d | 4d |  | 0% |  |
| 2 | 1.1 | **Hindalco RNSG Inputs** |  | 34d | 2021-10-25 | 2021-12-22 |  | 2021-10-25 | 2021-12-22 | 34d | 22d |  | 0% |  |
| 3 | 1.1.1 | Space for Site Office, FGD & SAC. Fab.Yrd, Engg. Qrts |  | 3d | 2021-10-25 | 2021-10-28 | 10FS-4d | 2021-10-25 | 2021-10-28 | 3d | 256.4d | 32d |  |  |
| 4 | 1.1.2 | Allocation of Engineers Quarters for Guest House (Chargeable Basis) |  | 3d | 2021-10-25 | 2021-10-28 | 10FS-4d | 2021-10-25 | 2021-10-28 | 3d | 365.4d |  |  |  |
| 5 | 1.1.3 | Existing SLD |  | 10d | 2021-11-01 | 2021-11-17 | 10 | 2021-11-01 | 2021-11-17 | 10d | 354.4d |  |  |  |
| 6 | 1.1.4 | Soil testing report of the identified FGD & SAC location |  | 30d | 2021-11-01 | 2021-12-22 | 10 | 2021-11-01 | 2021-12-22 | 30d | 18d | 0d |  |  |
| 7 | 1.1.5 | Geotechnical Investigation/Update of Existing Plot location for FGD plant |  | 20d | 2021-11-17 | 2021-12-22 | 6SS+10d | 2021-11-17 | 2021-12-22 | 20d | 18d | 0d |  |  |
| 8 | 1.1.6 | Availability of Steam at 17.5 bar & 4.5 bar at SAC battery limit at saturated condition |  | 15d | 2021-11-01 | 2021-11-25 | 10 | 2021-11-01 | 2021-11-25 | 15d | 349.4d |  |  |  |
| 9 | 1.2 | **Wl Gore Inputs and General Activities** |  | 30d | 2021-11-01 | 2021-12-22 |  | 2021-11-01 | 2021-12-22 | 30d | 0d |  | 0% |  |
| 10 | 1.2.1 | Notice of Award | milestone | 0d | 2021-11-01 | 2021-11-01 |  | 2021-11-01 | 2021-11-01 | 0d | 0d |  |  |  |
| 11 | 1.2.2 | Preparation of Complete Engineering deliverable list (EDL) (Preliminary) |  | 5d | 2021-11-01 | 2021-11-09 | 10 | 2021-11-01 | 2021-11-09 | 5d | 25d |  |  | RPDU5.BA.002 |
| 12 | 1.2.3 | Process details to be provided by M/s WL Gore |  | 3d | 2021-11-01 | 2021-11-04 | 10 | 2021-11-01 | 2021-11-09 | 5d | 27d | 0d |  |  |
| 13 | 1.2.4 | **FGD - Performance Curve Inlet Sox vs. Outlet Sox** |  | 27d | 2021-11-01 | 2021-12-16 |  | 2021-11-01 | 2021-12-16 | 27d | 3d |  | 0% | RPDU5.PG.002 |
| 14 | 1.2.4.1 | FGD - Performance Curve Inlet Sox vs. Outlet Sox (First Submission) |  | 9d | 2021-11-01 | 2021-11-16 |  | 2021-11-01 | 2021-11-16 | 9d | 3d | 0d |  | RPDU5.PG.002 |
| 15 | 1.2.4.2 | FGD - Performance Curve Inlet Sox vs. Outlet Sox (Second Submission) |  | 18d | 2021-11-16 | 2021-12-16 | 14 | 2021-11-16 | 2021-12-16 | 18d | 3d |  |  | RPDU5.PG.002 |
| 16 | 1.2.5 | **FGD - Specification of Performance Guaranteed Parameters** |  | 27d | 2021-11-01 | 2021-12-16 |  | 2021-11-01 | 2021-12-16 | 27d | 3d |  | 0% | RPDU5.PG.003 |
| 17 | 1.2.5.1 | FGD - Specification of Performance (First Submission) |  | 9d | 2021-11-01 | 2021-11-16 |  | 2021-11-01 | 2021-11-16 | 9d | 3d | 0d |  |  |
| 18 | 1.2.5.2 | FGD - Specification of Performance Guaranteed Parameters (Second Submission) |  | 18d | 2021-11-16 | 2021-12-16 | 17 | 2021-11-16 | 2021-12-16 | 18d | 3d |  |  |  |
| 19 | 1.2.6 | Module arrangement and support structures Philosophy |  | 30d | 2021-11-01 | 2021-12-22 | 10 | 2021-11-01 | 2021-12-22 | 30d | 0d |  |  |  |
| 20 | 1.3 | **Master project Schedule** |  | 30d | 2021-12-15 | 2022-02-04 |  | 2021-12-15 | 2022-03-11 | 50d | 308.4d |  | 0% |  |
| 21 | 1.3.1 | Preparation of Master Project Schedule-(First Submission) |  | 30d | 2021-12-15 | 2022-02-04 | 10FS+26d | 2021-12-15 | 2022-02-04 | 30d | 308.4d |  |  | RPDU5.BA.001 |
| 22 | 1.4 | **Engineering FGD & SAC** |  | 140d | 2021-11-01 | 2022-07-01 |  | 2021-11-01 | 2022-07-07 | 143d | 34d |  | 0% |  |
| 23 | 1.4.1 | **Process Engineering FGD & SAC** |  | 18d | 2021-11-01 | 2021-12-01 |  | 2021-11-01 | 2022-03-15 | 77d | 34d |  | 0% |  |
| 24 | 1.4.1.1 | **FGD Process** |  | 18d | 2021-11-01 | 2021-12-01 |  | 2021-11-01 | 2022-03-10 | 75d | 34d |  | 0% |  |
| 25 | 1.4.1.1.1 | **FGD - Process Flow Diagram with Mass Balance** |  | 9d | 2021-11-01 | 2021-11-16 |  | 2021-11-01 | 2022-01-26 | 50d | 34d |  | 0% | RPDU5.MP.001 |
| 26 | 1.4.1.1.1.1 | FGD - Process Flow Diagram with Mass Balance (First Submission) |  | 9d | 2021-11-01 | 2021-11-16 | 10, 12SS | 2021-11-01 | 2021-11-17 | 10d | 34d | 0d |  | RPDU5.MP.001 |

| ID | WBS | Task | Duration | Start | Finish | Predecessors | Baseline start | Baseline finish | Baseline duration | Total slack | Free slack | Planned % Complete | WLG Drg |
| --- | --- | --- | --- | --- | --- | --- | --- | --- | --- | --- | --- | --- | --- |
| 27 | 1.4.1.1.2 | **FGD - Computerized Fluid-dynamic Simulation (CFD)** | 18d | 2021-11-01 | 2021-12-01 |  | 2021-11-01 | 2022-02-25 | 68d | 346.4d |  | 0% | RPDU5.MA.001 |
| 28 | 1.4.1.1.2.1 | FGD - Computerized Fluid-dynamic Simulation (CFD)- (First Submission) | 18d | 2021-11-01 | 2021-12-01 | 10 | 2021-11-01 | 2021-12-22 | 30d | 346.4d |  |  |  |
| 29 | 1.4.1.1.3 | **FGD & SAC - Media Specification** | 9d | 2021-11-16 | 2021-12-01 |  | 2021-11-01 | 2022-01-26 | 50d | 346.4d |  | 0% | RPDU5.MP.500 |
| 30 | 1.4.1.1.3.1 | FGD & SAC - Media Specification (First Submission) | 9d | 2021-11-16 | 2021-12-01 | 26 | 2021-11-01 | 2021-11-17 | 10d | 346.4d |  |  | RPDU5.MP.500 |
| 31 | 1.4.1.1.4 | **FGD - Process and Instrumentation Diagrams (with KKS or other Hindalco numbering System)** | 9d | 2021-11-16 | 2021-12-01 |  | 2021-12-14 | 2022-03-10 | 50d | 224.4d |  | 0% | RPDU5.MP.010 |
| 32 | 1.4.1.1.4.1 | FGD - Process and Instrumentation Diagrams - (First Submission) | 9d | 2021-11-16 | 2021-12-01 | 26 | 2021-12-14 | 2021-12-30 | 10d | 224.4d | 0d |  | RPDU5.MP.010 |
| 33 | 1.4.1.1.5 | **FGD -Equipment List** | 9d | 2021-11-16 | 2021-12-01 |  | 2021-11-17 | 2022-02-11 | 50d | 111.4d |  | 0% | RPDU5.MM.000 |
| 34 | 1.4.1.1.5.1 | FGD -Equipment List(First Submission) | 9d | 2021-11-16 | 2021-12-01 | 26 | 2021-11-17 | 2021-12-03 | 10d | 111.4d | 0d |  | RPDU5.MM.000 |
| 35 | 1.4.1.1.6 | **FGD - Technical Specification with equipment sizing** | 9d | 2021-11-16 | 2021-12-01 |  | 2021-11-17 | 2022-03-02 | 60d | 34d |  | 0% | RPDU5.PG.001 |
| 36 | 1.4.1.1.6.1 | FGD - Technical Specification with equipment sizing (First Submission) | 9d | 2021-11-16 | 2021-12-01 | 26, 12SS | 2021-11-17 | 2021-12-22 | 20d | 34d | 0d |  |  |
| 37 | 1.4.1.2 | **SAC Process** | 18d | 2021-11-01 | 2021-12-01 |  | 2021-11-01 | 2022-03-15 | 77d | 224.4d |  | 0% |  |
| 38 | 1.4.1.2.1 | **SAC - Process Flow Diagram with Mass Balance** | 9d | 2021-11-01 | 2021-11-16 |  | 2021-12-22 | 2022-03-15 | 47d | 224.4d |  | 0% | RPDU5.MP.301 |
| 39 | 1.4.1.2.1.1 | SAC - Process Flow Diagram with Mass Balance (First Submission) | 9d | 2021-11-01 | 2021-11-16 | 10, 12SS | 2021-12-22 | 2022-01-26 | 20d | 224.4d | 0d |  | RPDU5.MP.301 |
| 40 | 1.4.1.2.2 | **SAC - Technical Specification with equipment sizing** | 9d | 2021-11-16 | 2021-12-01 |  | 2021-11-01 | 2022-02-03 | 55d | 224.4d |  | 0% | RPDU5.PG.301 |
| 41 | 1.4.1.2.2.1 | SAC - Technical Specification with equipment sizing (First Submission) | 9d | 2021-11-16 | 2021-12-01 | 10, 39 | 2021-11-01 | 2021-12-22 | 30d | 224.4d | 0d |  |  |
| 42 | 1.4.1.2.3 | **SAC - Process and Instrumentation Diagrams (First Submission)** | 9d | 2021-11-16 | 2021-12-01 |  | 2022-01-18 | 2022-03-15 | 32d | 266.4d |  | 0% | RPDU5.MP.310 |
| 43 | 1.4.1.2.3.1 | SAC - Process and Instrumentation Diagrams (first Submission) | 9d | 2021-11-16 | 2021-12-01 | 39 | 2022-01-18 | 2022-02-03 | 10d | 266.4d | 0d |  | RPDU5.MP.310 |
| 44 | 1.4.1.2.4 | **SAC -Equipment List** | 9d | 2021-11-16 | 2021-12-01 |  | 2022-02-03 | 2022-03-15 | 22d | 266.4d |  | 0% | RPDU5.MM.000 |
| 45 | 1.4.1.2.4.1 | SAC -Equipment List (First Submission) | 9d | 2021-11-16 | 2021-12-01 | 39 | 2022-02-03 | 2022-03-10 | 20d | 266.4d | 0d |  | RPDU5.MM.000 |
| 46 | 1.4.1.2.5 | **SAC - Specification of Performance Guaranteed Parameters** | 9d | 2021-11-16 | 2021-12-01 |  | 2022-01-26 | 2022-03-15 | 27d | 346.4d |  | 0% | RPDU5.PG.303 |
| 47 | 1.4.1.2.5.1 | SAC - Specification of Performance Guaranteed Parameters(First Submission) | 9d | 2021-11-16 | 2021-12-01 | 39 | 2022-01-26 | 2022-02-11 | 10d | 346.4d |  |  |  |
| 48 | 1.4.2 | **General engineering FGD & SAC** | 100d | 2021-11-01 | 2022-04-22 |  | 2021-11-01 | 2022-05-11 | 110d | 48d |  | 0% |  |
| 49 | 1.4.2.1 | **FGD - General Arrangement Drawing (Overall Plot Plan)** | 10d | 2021-12-22 | 2022-01-07 |  | 2021-12-22 | 2022-04-06 | 60d | 18d |  | 0% | RPDU5.ML.000 |
| 50 | 1.4.2.1.1 | FGD - General Arrangement Drawing (Overall Plot Plan)- (First Submission) | 10d | 2021-12-22 | 2022-01-07 | 36SS+5d, 6, 7, 26 | 2021-12-22 | 2022-01-07 | 10d | 18d | 0d |  |  |

| ID | WBS | Task | Duration | Start | Finish | Predecessors | Baseline start | Baseline finish | Baseline duration | Total slack | Free slack | Planned % Complete | WLG Drg |
| --- | --- | --- | --- | --- | --- | --- | --- | --- | --- | --- | --- | --- | --- |
| 51 | 1.4.2.2 | **FGD - General Arrangement Drawings (Plans and Sections)** | 10d | 2022-01-10 | 2022-01-26 |  | 2022-01-10 | 2022-05-11 | 70d | 314.4d |  | 0% | RPDU5.ML.001 |
| 52 | 1.4.2.2.1 | FGD - General Arrangement Drawings (Plans and Sections)-(First Submission) | 10d | 2022-01-10 | 2022-01-26 | 50SS+10d | 2022-01-10 | 2022-02-11 | 20d | 314.4d |  |  |  |
| 53 | 1.4.2.3 | **SAC- General Arrangement Drawing (Overall Plot Plan)** | 20d | 2021-12-02 | 2022-01-06 |  | 2021-11-17 | 2022-03-18 | 70d | 233.4d |  | 0% | RPDU5.ML.300 |
| 54 | 1.4.2.3.1 | SAC- General Arrangement Drawing (Overall Plot Plan)-(First Submission) | 20d | 2021-12-02 | 2022-01-06 | 41SS+10d | 2021-11-17 | 2021-12-22 | 20d | 233.4d | 0d |  |  |
| 55 | 1.4.2.4 | **SAC - General Arrangement Drawings (Plans and Sections)** | 20d | 2021-12-21 | 2022-01-25 |  | 2021-12-06 | 2022-04-06 | 70d | 315.4d |  | 0% | RPDU5.ML.301 |
| 56 | 1.4.2.4.1 | SAC - General Arrangement Drawings (Plans and Sections)-(First Submission) | 20d | 2021-12-21 | 2022-01-25 | 54SS+10d | 2021-12-06 | 2022-01-07 | 20d | 315.4d |  |  |  |
| 57 | 1.4.2.5 | Project Quality Control Manual (with Job Organization Chart) | 30d | 2021-11-01 | 2021-12-22 | 10 | 2021-11-01 | 2021-12-22 | 30d | 334.4d |  |  |  |
| 58 | 1.4.2.6 | HAZOP study and ARM analysis (Availability, Reliability & Maintainability) | 30d | 2022-03-02 | 2022-04-22 | 50FS+30d | 2022-03-02 | 2022-04-22 | 30d | 264.4d |  |  | RPDU5.QB.505 |
| 59 | 1.4.3 | **FGD & SAC - CIVIL** | 71d | 2021-12-28 | 2022-04-29 |  | 2022-01-17 | 2022-06-03 | 80d | 26d |  | 0% |  |
| 60 | 1.4.3.1 | **FGD- Civil** | 45d | 2022-02-10 | 2022-04-29 |  | 2022-01-17 | 2022-06-03 | 80d | 0d |  | 0% |  |
| 61 | 1.4.3.1.1 | **FGD Electrical Buildings (Control Room) - Architectural Outline Drawings (Plans and Sections)** | 45d | 2022-02-10 | 2022-04-29 |  | 2022-02-10 | 2022-05-12 | 52d | 0d |  | 0% | RPDU5.ML.501 |
| 62 | 1.4.3.1.1.1 | FGD Electrical Buildings (Control Room) - Architectural Outline Drawings (Plans and Sections)-(First Submission) | 45d | 2022-02-10 | 2022-04-29 | 9FS+29d | 2022-02-10 | 2022-03-03 | 12d | 0d |  |  |  |
| 63 | 1.4.3.1.2 | **FGD - Foundation Layout Drawings with equipment loads and embedded parts/ Civil assignment drawing with Load Data** | 45d | 2022-02-10 | 2022-04-29 |  | 2022-01-17 | 2022-06-03 | 80d | 18d |  | 0% | RPDU5.MC.001 |
| 64 | 1.4.3.1.2.1 | FGD - Foundation Layout Drawings with equipment loads and embedded parts/ Civil assignment drawing with Load Data-(First Submission) | 45d | 2022-02-10 | 2022-04-29 | 36, 50FS+19d | 2022-01-17 | 2022-03-25 | 40d | 18d | 0d |  |  |
| 65 | 1.4.3.1.2.2 | FGD - Seismic Calculation Report of the foundations | 20d | 2022-03-28 | 2022-04-29 | 64FS-20d | 2022-05-18 | 2022-06-03 | 10d | 260.4d |  |  | RPDU5.MA.001 |
| 66 | 1.4.3.2 | **SAC- Civil** | 60d | 2021-12-28 | 2022-04-12 |  | 2022-01-17 | 2022-05-03 | 61d | 224.4d |  | 0% |  |
| 67 | 1.4.3.2.1 | **SAC Buildings - Architectural Outline Drawings (Plans and Sections)** | 60d | 2021-12-28 | 2022-04-12 |  | 2022-01-18 | 2022-05-03 | 60d | 224.4d |  | 0% | RPDU5.ML.551 |
| 68 | 1.4.3.2.1.1 | SAC Buildings - Architectural Outline Drawings (Plans and Sections)- (First Submission) | 15d | 2021-12-28 | 2022-01-21 | 3FS+2d, 41FS+15d | 2022-01-18 | 2022-02-11 | 15d | 224.4d | 0d |  |  |
| 69 | 1.4.3.2.1.2 | SAC Buildings - Architectural Outline Drawings (Plans and Sections)- (Second Submission) | 15d | 2022-03-16 | 2022-04-12 | 68FS+30d | 2022-04-06 | 2022-05-03 | 15d | 271.4d |  |  |  |
| 70 | 1.4.3.2.2 | **SAC - Foundation Layout Drawings with equipment loads and embedded parts/ Civil assignment drawing with Load Data** | 34d | 2022-01-17 | 2022-03-16 |  | 2022-01-17 | 2022-03-16 | 34d | 286.4d |  | 0% | RPDU5.MC.301 |
| 71 | 1.4.3.2.2.1 | SAC - Foundation Layout Drawings with equipment loads and embedded parts/ Civil assignment drawing with Load Data-(First Submission) | 17d | 2022-01-17 | 2022-02-15 | 41, 50FS+4d | 2022-01-17 | 2022-02-15 | 17d | 286.4d | 0d |  |  |
| 72 | 1.4.3.2.2.2 | SAC - Foundation Layout Drawings with equipment loads and embedded parts/ Civil assignment drawing with Load Data-(Second Submission) | 17d | 2022-02-15 | 2022-03-16 | 71 | 2022-02-15 | 2022-03-16 | 17d | 286.4d | 0d |  |  |
| 73 | 1.4.3.2.2.3 | SAC - Seismic Calculation Report of the foundations | 17d | 2022-02-15 | 2022-03-16 | 72SS | 2022-02-15 | 2022-03-16 | 17d | 286.4d |  |  | RPDU5.MA.301 |
| 74 | 1.4.4 | **FGD Detail Engineering** | 86d | 2021-12-01 | 2022-04-29 |  | 2021-12-15 | 2022-07-05 | 115d | 238.4d |  | 0% |  |
| 75 | 1.4.4.1 | **FGTR** | 79d | 2021-12-14 | 2022-04-29 |  | 2021-12-15 | 2022-06-24 | 110d | 231.4d |  | 0% |  |
| 76 | 1.4.4.1.1 | FGD - FGTR Flue Gas Treatment Reactor - Mechanical Calculation according to Indian Standard (latest edition) | 20d | 2021-12-14 | 2022-01-18 | 36SS+16d | 2021-12-15 | 2022-01-19 | 20d | 231.4d | 0d |  | RPDU5.MA.002 |

| ID | WBS | Task | Duration | Start | Finish | Predecessors | Baseline start | Baseline finish | Baseline duration | Total slack | Free slack | Planned % Complete | WLG Drg |
| --- | --- | --- | --- | --- | --- | --- | --- | --- | --- | --- | --- | --- | --- |
| 77 | 1.4.4.1.2 | **FGD - FGTR Flue Gas Treatment Reactor - Outline Drawing (including hoppers, supporting steel structure, , stairs and platforms) with design data, nozzles chart and loads on foundation** | 25d | 2022-01-26 | 2022-03-10 |  | 2022-01-27 | 2022-06-24 | 85d | 259.4d |  | 0% | RPDU5.MV.003 |
| 78 | 1.4.4.1.2.1 | FGD - FGTR Flue Gas Treatment Reactor - Outline Drawing (including hoppers, supporting steel structure, , stairs and platforms) with design data, nozzles chart and loads on foundation-(First Submission) | 25d | 2022-01-26 | 2022-03-10 | 76FS+5d | 2022-01-27 | 2022-03-11 | 25d | 259.4d | 0d |  |  |
| 79 | 1.4.4.1.3 | FGD - FGTR - Spring Details | 19d | 2022-03-29 | 2022-04-29 | 78FS+10d | 2022-05-23 | 2022-06-24 | 20d | 260.4d | 0d |  | RPDU5.MV.502 |
| 80 | 1.4.4.1.4 | FGD - FGTR - Slider Bearings Details | 19d | 2022-03-29 | 2022-04-29 | 79SS | 2022-05-23 | 2022-06-24 | 20d | 260.4d |  |  | RPDU5.MV.501 |
| 81 | 1.4.4.1.5 | FGD - FGTR Flue Gas Treatment Reactor - Construction Drawings (including hoppers, supporting steel structure, stairs and platforms) | 19d | 2022-03-29 | 2022-04-29 | 78FS+10d, 19 | 2022-03-30 | 2022-06-08 | 40d | 260.4d |  |  | RPDU5.MV.004 |
| 82 | 1.4.4.1.6 | STAAD Pro Analysis | 30d | 2022-01-18 | 2022-03-10 | 76SS+20d | 2022-01-19 | 2022-03-11 | 30d | 289.4d |  |  |  |
| 83 | 1.4.4.2 | **Wet Stack** | 79d | 2021-12-14 | 2022-04-29 |  | 2021-12-15 | 2022-07-05 | 115d | 231.4d |  | 0% |  |
| 84 | 1.4.4.2.1 | FGD - Wet Stack - Mechanical Calculation according to Indian Standard (latest edition) | 20d | 2021-12-14 | 2022-01-18 | 36SS+14d, 76SS | 2021-12-15 | 2022-01-19 | 20d | 231.4d | 0d |  | RPDU5.MA.005 |
| 85 | 1.4.4.2.2 | **FGD - Wet Stack - Outline Drawing (including hoppers, supporting steel structure, , stairs and platforms) with design data, nozzles chart and loads** | 25d | 2022-02-03 | 2022-03-18 |  | 2022-02-07 | 2022-07-05 | 85d | 231.4d |  | 0% | RPDU5.MV.005 |
| 86 | 1.4.4.2.2.1 | FGD - Wet Stack - Outline Drawing (including hoppers, supporting steel structure, , stairs and platforms) with design data, nozzles chart and loads- (First Submission) | 25d | 2022-02-03 | 2022-03-18 | 84FS+10d | 2022-02-07 | 2022-03-22 | 25d | 231.4d | 0d |  |  |
| 87 | 1.4.4.2.3 | FGD - Wet Stack - Construction Drawings (including hoppers, supporting steel structure, , stairs and platforms) | 19d | 2022-03-29 | 2022-04-29 | 86FS+5d | 2022-04-18 | 2022-06-24 | 40d | 260.4d | 0d |  | RPDU5.MV.006 |
| 88 | 1.4.4.3 | **MCU** | 79d | 2021-12-14 | 2022-04-29 |  | 2021-12-15 | 2022-07-05 | 115d | 254.4d |  | 0% |  |
| 89 | 1.4.4.3.1 | FGD - MCU Mist Cooling Unit - Mechanical Calculation according to Indian Standard (latest edition) | 20d | 2021-12-14 | 2022-01-18 | 36SS+16d, 12 | 2021-12-15 | 2022-01-19 | 20d | 254.4d | 0d |  | RPDU5.MA.001 |
| 90 | 1.4.4.3.2 | **FGD - MCU Mist Cooling Unit - Outline Drawing (including hoppers, supporting steel structure, stairs and platforms) with design data, nozzles chart and loads on foundation** | 25d | 2022-02-03 | 2022-03-18 |  | 2022-02-07 | 2022-06-16 | 75d | 254.4d |  | 0% | RPDU5.MV.001 |
| 91 | 1.4.4.3.2.1 | FGD - MCU Mist Cooling Unit - Outline Drawing (including hoppers, supporting steel structure, stairs and platforms) with design data, nozzles chart and loads on foundation-(First Submission) | 25d | 2022-02-03 | 2022-03-18 | 89FS+10d | 2022-02-07 | 2022-03-22 | 25d | 254.4d | 0d |  |  |
| 92 | 1.4.4.3.3 | FGD - MCU - Slider Bearings Details | 14d | 2022-04-06 | 2022-04-29 | 91FS+10d | 2022-05-31 | 2022-06-16 | 10d | 260.4d | 0d |  | RPDU5.MV.501 |
| 93 | 1.4.4.3.4 | FGD - MCU - Spring Details | 14d | 2022-04-06 | 2022-04-29 | 92SS | 2022-05-31 | 2022-06-16 | 10d | 260.4d |  |  | RPDU5.MV.502 |
| 94 | 1.4.4.3.5 | FGD - MCU Mist Cooling Unit - Construction Drawings (including hoppers, supporting steel structure, stairs and platforms) | 14d | 2022-04-06 | 2022-04-29 | 91SS+10d, 19, 87SS+5d | 2022-04-26 | 2022-07-05 | 40d | 260.4d |  |  | RPDU5.MV.002 |
| 95 | 1.4.4.4 | **Flue gas ducting** | 69d | 2021-12-30 | 2022-04-29 |  | 2021-12-15 | 2022-06-24 | 110d | 260.4d |  | 0% |  |
| 96 | 1.4.4.4.1 | **FGD - Flue Gas Ducts (including supporting structures, stairs and platforms) - Outline Drawings** | 69d | 2021-12-30 | 2022-04-29 |  | 2021-12-15 | 2022-06-08 | 100d | 260.4d |  | 0% |  |
| 97 | 1.4.4.4.1.1 | FGD - Flue Gas Ducts (including supporting structures, stairs and platforms) - Outline Drawings-(First Submission) | 30d | 2021-12-30 | 2022-02-22 | 54SS+16d | 2021-12-15 | 2022-02-04 | 30d | 260.4d | 0d |  | RPDU5.MU.001 |
| 98 | 1.4.4.4.1.2 | FGD - Flue Gas Ducts Supporting Steel Structures (including supporting structures, stairs and platforms) - Construction Drawings | 29d | 2022-03-10 | 2022-04-29 | 97FS+10d | 2022-03-30 | 2022-06-24 | 50d | 260.4d |  |  | RPDU5.MU.002 |
| 99 | 1.4.4.5 | **Tanks** | 79d | 2021-12-14 | 2022-04-29 |  | 2021-12-15 | 2022-03-11 | 50d | 260.4d |  | 0% |  |
| 100 | 1.4.4.5.1 | **FGD - Process Water Tank - Outline Drawing with design data, nozzles chart and loads** | 60d | 2021-12-14 | 2022-03-29 |  | 2021-12-15 | 2022-02-23 | 40d | 260.4d |  | 0% | RPDU5.MV.010 |
| 101 | 1.4.4.5.1.1 | FGD - Process Water Tank - Outline Drawing with design data, nozzles chart and loads-(First Submission) | 15d | 2021-12-14 | 2022-01-07 | 36SS+16d | 2021-12-15 | 2021-12-23 | 5d | 260.4d | 0d |  |  |
| 102 | 1.4.4.5.1.2 | FGD - Process Water Tank - Outline Drawing with design data, nozzles chart and loads-(Second Submission) | 15d | 2022-03-02 | 2022-03-29 | 101FS+30d | 2022-02-15 | 2022-02-23 | 5d | 260.4d | 0d |  |  |
| 103 | 1.4.4.5.2 | FGD - Process Water Tank - Construction Drawings | 24d | 2022-03-21 | 2022-04-29 | 102SS+10d | 2022-03-03 | 2022-03-11 | 5d | 260.4d | 0d |  | RPDU5.MV.011 |

| ID | WBS | Task | Duration | Start | Finish | Predecessors | Baseline start | Baseline finish | Baseline duration | Total slack | Free slack | Planned % Complete | WLG Drg |
| --- | --- | --- | --- | --- | --- | --- | --- | --- | --- | --- | --- | --- | --- |
| 104 | 1.4.4.5.3 | **FGD - Waste Recycle Tank - Outline Drawing with design data, nozzles chart and loads** | 60d | 2021-12-14 | 2022-03-29 |  | 2021-12-15 | 2022-02-23 | 40d | 279.4d |  | 0% | RPDU5.MV.012 |
| 105 | 1.4.4.5.3.1 | FGD - Waste Recycle Tank - Outline Drawing with design data, nozzles chart and loads--(First Submission) | 15d | 2021-12-14 | 2022-01-07 | 101SS | 2021-12-15 | 2021-12-23 | 5d | 324.4d |  |  |  |
| 106 | 1.4.4.5.3.2 | FGD - Waste Recycle Tank - Outline Drawing with design data, nozzles chart and loads-(Second Submission) | 15d | 2022-03-02 | 2022-03-29 | 102SS | 2022-02-15 | 2022-02-23 | 5d | 279.4d |  |  |  |
| 107 | 1.4.4.5.4 | FGD - Waste Recycle Tank - Construction Drawings | 24d | 2022-03-21 | 2022-04-29 | 103SS | 2022-03-03 | 2022-03-11 | 5d | 260.4d |  |  | RPDU5.MV.013 |
| 108 | 1.4.4.6 | **Piping** | 86d | 2021-12-01 | 2022-04-29 |  | 2021-12-15 | 2022-04-06 | 64d | 260.4d |  | 0% |  |
| 109 | 1.4.4.6.1 | FGD - Piping Line List | 20d | 2021-12-01 | 2022-01-05 | 32SS+1d, 34 | 2021-12-15 | 2021-12-31 | 10d | 326.4d | 0d |  | RPDU5.MM.001 |
| 110 | 1.4.4.6.2 | FGD - Piping Materials Specification | 20d | 2021-12-01 | 2022-01-05 | 109SS | 2021-12-15 | 2022-01-11 | 15d | 326.4d |  |  | RPDU5.PG.010 |
| 111 | 1.4.4.6.3 | FGD - Piping Isometric Drawings with bill of quantities and support location identification | 30d | 2022-02-03 | 2022-03-29 | 50FS+15d | 2022-01-26 | 2022-03-18 | 30d | 260.4d | 0d |  | RPDU5.MS.010 |
| 112 | 1.4.4.6.4 | FGD - Piping Layout (Plans and Sections) with pipe supports location identification | 30d | 2022-03-09 | 2022-04-29 | 111SS+19d | 2022-02-14 | 2022-04-06 | 30d | 260.4d | 0d |  | RPDU5.ML.010 |
| 113 | 1.4.4.6.5 | FGD - Pipe Racks and Access Platforms for Maintenance - Drawings with bill of quantities | 20d | 2022-03-28 | 2022-04-29 | 112SS+10d | 2022-03-02 | 2022-04-06 | 20d | 260.4d | 0d |  | RPDU5.MU.010 |
| 114 | 1.4.4.6.6 | FGD - Pipe Supports - Drawings with bill of quantities | 30d | 2022-03-09 | 2022-04-29 | 112SS | 2022-03-02 | 2022-04-06 | 20d | 260.4d |  |  | RPDU5.MU.050 |
| 115 | 1.4.5 | **SAC Basic & Detail Engineering** | 69d | 2021-12-30 | 2022-04-29 |  | 2021-12-15 | 2022-04-15 | 70d | 255.4d |  | 0% |  |
| 116 | 1.4.5.1 | **Supporting structures** | 69d | 2021-12-30 | 2022-04-29 |  | 2021-12-15 | 2022-04-15 | 70d | 255.4d |  | 0% |  |
| 117 | 1.4.5.1.1 | **SAC - Equipment Supporting Steel Structures (including stairs and platforms)** | 15d | 2021-12-30 | 2022-01-26 |  | 2021-12-15 | 2022-03-11 | 50d | 255.4d |  | 0% | RPDU5.MV.301 |
| 118 | 1.4.5.1.1.1 | SAC - Equipment Supporting Steel Structures (including stairs and platforms) - Outline Drawings-(First submission) | 15d | 2021-12-30 | 2022-01-26 | 54SS+16d | 2021-12-15 | 2021-12-31 | 10d | 255.4d | 0d |  |  |
| 119 | 1.4.5.1.2 | SAC - Equipment Supporting Steel Structures (including stairs and platforms) - Construction Drawings | 54d | 2022-01-26 | 2022-04-29 | 118 | 2022-01-03 | 2022-04-15 | 60d | 260.4d |  |  | RPDU5.MV.302 |
| 120 | 1.4.5.2 | **SAC-Piping** | 69d | 2021-12-30 | 2022-04-29 |  | 2021-12-15 | 2022-04-14 | 69d | 260.4d |  | 0% |  |
| 121 | 1.4.5.2.1 | SAC - Piping Line List | 10d | 2021-12-30 | 2022-01-18 | 41SS+26d | 2021-12-15 | 2021-12-31 | 10d | 309.4d | 0d |  | RPDU5.MM.301 |
| 122 | 1.4.5.2.2 | SAC - Piping Materials Specification | 10d | 2021-12-30 | 2022-01-18 | 121SS | 2021-12-15 | 2021-12-31 | 10d | 319.4d |  |  | RPDU5.PG.310 |
| 123 | 1.4.5.2.3 | SAC - Piping Isometric Drawings with bill of quantities and support location identification | 30d | 2022-01-25 | 2022-03-17 | 54FS+10d | 2022-01-10 | 2022-03-02 | 30d | 262.4d | 0d |  | RPDU5.MS.310 |
| 124 | 1.4.5.2.4 | SAC - Piping Layout (Plans and Sections) with pipe supports location identification | 30d | 2022-01-31 | 2022-03-23 | 54FS+10d, 123SS+3d | 2022-01-13 | 2022-03-08 | 30d | 262.4d | 0d |  | RPDU5.ML.310 |
| 125 | 1.4.5.2.5 | SAC - Pipe Supports - Drawings with bill of quantities | 20d | 2022-02-16 | 2022-03-23 | 124SS+10d | 2022-02-01 | 2022-03-08 | 20d | 282.4d |  |  | RPDU5.MU.350 |
| 126 | 1.4.5.2.6 | SAC - Pipe Racks and Access Platforms for Maintenance - Drawings with bill of quantitites | 20d | 2022-03-28 | 2022-04-29 | 54, 123SS, 113SS | 2022-03-02 | 2022-04-06 | 20d | 260.4d |  |  | RPDU5.MU.310 |
| 127 | 1.4.5.2.7 | SAC - Stress Analysis Calculation of piping steam lines | 20d | 2022-03-23 | 2022-04-27 | 45, 54, 123, 124 | 2022-03-10 | 2022-04-14 | 20d | 262.4d |  |  | RPDU5.MA.302 |

| ID | WBS | Task | Duration | Start | Finish | Predecessors | Baseline start | Baseline finish | Baseline duration | Total slack | Free slack | Planned % Complete | WLG Drg |
| --- | --- | --- | --- | --- | --- | --- | --- | --- | --- | --- | --- | --- | --- |
| 128 | 1.4.6 | **FGD & SAC - Instrumentation & Control System** | 122d | 2021-12-01 | 2022-07-01 |  | 2022-01-13 | 2022-07-07 | 100d | 224.4d |  | 0% |  |
| 129 | 1.4.6.1 | **FGD** | 122d | 2021-12-01 | 2022-07-01 |  | 2022-01-13 | 2022-07-07 | 100d | 224.4d |  | 0% |  |
| 130 | 1.4.6.1.1 | **FGD - Valve List** | 80d | 2021-12-16 | 2022-05-05 |  | 2022-01-13 | 2022-04-28 | 60d | 224.4d |  | 0% | RPDU5.MM.002 |
| 131 | 1.4.6.1.1.1 | Valve List (First Submission) | 25d | 2021-12-16 | 2022-01-28 | 32SS+18d | 2022-01-13 | 2022-02-01 | 10d | 224.4d | 0d |  |  |
| 132 | 1.4.6.1.1.2 | Valve List (Second Submission) | 25d | 2022-03-23 | 2022-05-05 | 131FS+30d | 2022-03-24 | 2022-04-28 | 20d | 257.4d |  |  |  |
| 133 | 1.4.6.1.2 | FGD - On/Off Valves - Data Sheets | 25d | 2022-02-16 | 2022-03-31 | 131FS+10d | 2022-02-17 | 2022-03-08 | 10d | 277.4d |  |  | RPDU5.PG.060 |
| 134 | 1.4.6.1.3 | FGD - Control Valves - Data Sheets | 25d | 2022-02-16 | 2022-03-31 | 131FS+10d | 2022-02-17 | 2022-03-08 | 10d | 277.4d |  |  | RPDU5.PG.061 |
| 135 | 1.4.6.1.4 | **FGD - Instrument List** | 90d | 2021-12-16 | 2022-05-24 |  | 2022-01-13 | 2022-04-28 | 60d | 224.4d |  | 0% | RPDU5.EM.001 |
| 136 | 1.4.6.1.4.1 | FGD - Instrument List-(First Submission) | 30d | 2021-12-16 | 2022-02-08 | 32SS+18d | 2022-01-13 | 2022-02-01 | 10d | 224.4d | 0d |  |  |
| 137 | 1.4.6.1.4.2 | FGD - Instrument List-(Second Submission) | 30d | 2022-03-31 | 2022-05-24 | 136FS+30d | 2022-03-24 | 2022-04-28 | 20d | 224.4d | 0d |  |  |
| 138 | 1.4.6.1.5 | FGD - Measurement List | 30d | 2022-02-08 | 2022-03-31 | 136 | 2022-02-01 | 2022-03-08 | 20d | 254.4d | 30d |  | RPDU5.EM.002 |
| 139 | 1.4.6.1.6 | FGD - Operations & Controls Description | 30d | 2021-12-01 | 2022-01-21 | 32, 26 | 2022-01-13 | 2022-03-24 | 40d | 316.4d |  |  | RPDU5.PG.070 |
| 140 | 1.4.6.1.7 | **FGD - Input/Output List** | 60d | 2021-12-16 | 2022-03-31 |  | 2022-01-13 | 2022-04-28 | 60d | 277.4d |  | 0% | RPDU5.EM.003 |
| 141 | 1.4.6.1.7.1 | FGD - Input/Output List- (First Submission) | 10d | 2021-12-16 | 2022-01-04 | 136SS | 2022-01-13 | 2022-02-01 | 10d | 277.4d | 0d |  |  |
| 142 | 1.4.6.1.7.2 | FGD - Input/Output List- (Second Submission) | 20d | 2022-02-24 | 2022-03-31 | 141FS+30d | 2022-03-24 | 2022-04-28 | 20d | 277.4d |  |  |  |
| 143 | 1.4.6.1.8 | FGD - Instruments Data Sheets | 24d | 2022-02-08 | 2022-03-22 | 136 | 2022-02-01 | 2022-03-08 | 20d | 268.4d | 0d |  | RPDU5.ES.001 |
| 144 | 1.4.6.1.9 | FGD - Control Architecture Scheme | 24d | 2021-12-20 | 2022-01-28 | 32FS+10d | 2022-01-18 | 2022-03-10 | 30d | 302.4d | 0d |  | RPDU5.EL.050 |
| 145 | 1.4.6.1.10 | FGD - Control Room Layout Drawing | 24d | 2022-01-05 | 2022-02-16 | 144SS+10d | 2022-02-03 | 2022-03-29 | 30d | 302.4d |  |  | RPDU5.EL.052 |
| 146 | 1.4.6.1.11 | FGD - Loop Diagrams of main process sections | 24d | 2022-01-24 | 2022-03-04 | 32FS+30d | 2022-02-22 | 2022-04-14 | 30d | 267.4d | 0d |  | RPDU5.EL.001 |
| 147 | 1.4.6.1.12 | FGD - Junction Boxes Location Plan Drawing | 24d | 2022-03-31 | 2022-05-12 | 148SS | 2022-03-24 | 2022-04-28 | 20d | 253.4d |  |  | RPDU5.EL.054 |
| 148 | 1.4.6.1.13 | FGD - Instrument Location Plan Drawing | 25d | 2022-03-31 | 2022-05-13 | 136FS+30d, 32 | 2022-03-24 | 2022-05-17 | 30d | 224.4d | 0d |  | RPDU5.EL.353 |
| 149 | 1.4.6.1.14 | FGD - Hook-Up Diagrams | 23d | 2022-05-24 | 2022-07-01 | 137, 138 | 2022-04-28 | 2022-06-21 | 30d | 224.4d |  |  | RPDU5.EL.051 |
| 150 | 1.4.6.1.15 | FGD - Logic Diagrams | 25d | 2022-03-07 | 2022-04-19 | 146 | 2022-04-14 | 2022-06-07 | 30d | 267.4d |  |  | RPDU5.EL.010 |
| 151 | 1.4.6.1.16 | FGD- Control Cables list | 28d | 2022-05-16 | 2022-07-01 | 136, 148 | 2022-05-17 | 2022-07-07 | 30d | 224.4d |  |  | RPDU5.EM.004 |

| ID | WBS | Task | Duration | Start | Finish | Predecessors | Baseline start | Baseline finish | Baseline duration | Total slack | Free slack | Planned % Complete | WLG Drg |
| --- | --- | --- | --- | --- | --- | --- | --- | --- | --- | --- | --- | --- | --- |
| 152 | 1.4.6.2 | **SAC** | 122d | 2021-12-01 | 2022-07-01 |  | 2022-01-13 | 2022-06-15 | 87d | 224.4d |  | 0% |  |
| 153 | 1.4.6.2.1 | **SAC - Valve List** | 70d | 2021-12-16 | 2022-04-19 |  | 2022-01-13 | 2022-04-28 | 60d | 224.4d |  | 0% | RPDU5.MM.302 |
| 154 | 1.4.6.2.1.1 | SAC - Valve List-(First Submission) | 20d | 2021-12-16 | 2022-01-20 | 131SS | 2022-01-13 | 2022-02-01 | 10d | 224.4d | 0d |  |  |
| 155 | 1.4.6.2.1.2 | SAC - Valve List-(Second Submission) | 20d | 2022-03-15 | 2022-04-19 | 154FS+30d | 2022-03-24 | 2022-04-28 | 20d | 267.4d |  |  |  |
| 156 | 1.4.6.2.2 | SAC - On/Off Valves - Data Sheets | 20d | 2022-02-08 | 2022-03-15 | 154FS+10d | 2022-02-17 | 2022-03-08 | 10d | 287.4d |  |  | RPDU5.PG.360 |
| 157 | 1.4.6.2.3 | SAC - Control Valves - Data Sheets | 20d | 2022-02-08 | 2022-03-15 | 154FS+10d | 2022-02-17 | 2022-03-08 | 10d | 287.4d |  |  | RPDU5.PG.361 |
| 158 | 1.4.6.2.4 | **SAC - Instrument List** | 60d | 2021-12-16 | 2022-03-31 |  | 2022-01-13 | 2022-02-17 | 20d | 224.4d |  | 0% | RPDU5.EM.301 |
| 159 | 1.4.6.2.4.1 | SAC - Instrument List-(First Submission) | 30d | 2021-12-16 | 2022-02-08 | 154SS | 2022-01-13 | 2022-02-01 | 10d | 224.4d | 0d |  |  |
| 160 | 1.4.6.2.4.2 | SAC - Instrument List-(Second Submission) | 30d | 2022-02-08 | 2022-03-31 | 159 | 2022-02-01 | 2022-02-17 | 10d | 252.4d | 0d |  |  |
| 161 | 1.4.6.2.5 | SAC - Measurement List | 30d | 2022-02-08 | 2022-03-31 | 159 | 2022-02-01 | 2022-03-08 | 20d | 252.4d | 0d |  | RPDU5.EM.302 |
| 162 | 1.4.6.2.6 | SAC - Operations & Controls Description | 40d | 2021-12-01 | 2022-02-09 | 43 | 2022-02-03 | 2022-04-14 | 40d | 306.4d |  |  | RPDU5.PG.370 |
| 163 | 1.4.6.2.7 | **SAC - Input/Output List** | 50d | 2021-12-16 | 2022-03-15 |  | 2022-01-13 | 2022-03-08 | 30d | 284.4d |  | 0% | RPDU5.EM.303 |
| 164 | 1.4.6.2.7.1 | SAC - Input/Output List-(First Submission) | 25d | 2021-12-16 | 2022-01-28 | 159SS | 2022-01-13 | 2022-02-01 | 10d | 284.4d | 0d |  |  |
| 165 | 1.4.6.2.7.2 | SAC - Input/Output List-(Second Submission) | 25d | 2022-01-31 | 2022-03-15 | 164 | 2022-02-01 | 2022-03-08 | 20d | 287.4d |  |  |  |
| 166 | 1.4.6.2.8 | SAC - Instruments Data Sheets | 25d | 2022-02-24 | 2022-04-08 | 159FS+10d | 2022-02-17 | 2022-03-08 | 10d | 272.4d |  |  | RPDU5.ES.001 |
| 167 | 1.4.6.2.9 | SAC - Control Architecture Scheme | 25d | 2021-12-20 | 2022-02-01 | 43FS+10d | 2022-02-22 | 2022-04-14 | 30d | 301.4d | 0d |  | RPDU5.EL.350 |
| 168 | 1.4.6.2.10 | SAC - Control Room Layout Drawing | 25d | 2022-01-05 | 2022-02-17 | 167SS+10d | 2022-03-10 | 2022-03-29 | 10d | 301.4d |  |  | RPDU5.EL.352 |
| 169 | 1.4.6.2.11 | SAC - Loop Diagrams of main process sections | 25d | 2022-01-24 | 2022-03-08 | 43FS+30d | 2022-03-29 | 2022-05-19 | 30d | 266.4d | 0d |  | RPDU5.EL.301 |
| 170 | 1.4.6.2.12 | SAC - Logic Diagrams | 25d | 2022-03-08 | 2022-04-20 | 169 | 2022-05-19 | 2022-06-15 | 15d | 266.4d |  |  | RPDU5.EL.310 |
| 171 | 1.4.6.2.13 | SAC - Instrument Location Plan Drawing | 25d | 2022-03-31 | 2022-05-13 | 159FS+30d, 43 | 2022-03-24 | 2022-04-20 | 15d | 224.4d | 0d |  | RPDU5.EL.553 |
| 172 | 1.4.6.2.14 | SAC - Junction Boxes Location Plan Drawing | 25d | 2022-03-31 | 2022-05-13 | 171SS | 2022-03-24 | 2022-04-28 | 20d | 252.4d |  |  | RPDU5.EL.354 |
| 173 | 1.4.6.2.15 | SAC - Hook-Up Diagrams | 25d | 2022-03-31 | 2022-05-13 | 160, 161 | 2022-03-08 | 2022-04-28 | 30d | 252.4d |  |  | RPDU5.EL.351 |
| 174 | 1.4.6.2.16 | SAC- Control Cable List | 28d | 2022-05-16 | 2022-07-01 | 164, 171 | 2022-04-20 | 2022-05-06 | 10d | 224.4d |  |  | RPDU5.EM.304 |
| 175 | 1.4.7 | **FGD & SAC - Electrical system** | 122d | 2021-12-01 | 2022-07-01 |  | 2022-01-31 | 2022-07-06 | 90d | 224.4d |  | 0% |  |
| 176 | 1.4.7.1 | **FGD** | 122d | 2021-12-01 | 2022-07-01 |  | 2022-01-31 | 2022-07-06 | 90d | 224.4d |  | 0% |  |
| 177 | 1.4.7.1.1 | **FGD - Electrical Load /Drive List** | 20d | 2021-12-01 | 2022-01-05 |  | 2022-01-31 | 2022-04-27 | 50d | 224.4d |  | 0% | RPDU5.EM.000 |
| 178 | 1.4.7.1.1.1 | FGD - Electrical Load /Drive List-(First Submission) | 20d | 2021-12-01 | 2022-01-05 | 34 | 2022-01-31 | 2022-02-16 | 10d | 224.4d | 0d |  |  |

| ID | WBS | Task | Duration | Start | Finish | Predecessors | Baseline start | Baseline finish | Baseline duration | Total slack | Free slack | Planned % Complete | WLG Drg |
| --- | --- | --- | --- | --- | --- | --- | --- | --- | --- | --- | --- | --- | --- |
| 179 | 1.4.7.1.2 | **FGD - Electrical Single Line Diagram** | 102d | 2022-01-05 | 2022-07-01 |  | 2022-02-16 | 2022-07-06 | 80d | 224.4d |  | 0% | RPDU5.EG.001 |
| 180 | 1.4.7.1.2.1 | FGD - Electrical Single Line Diagram-(First Submission) | 40d | 2022-01-05 | 2022-03-16 | 178 | 2022-02-16 | 2022-03-23 | 20d | 224.4d | 0d |  |  |
| 181 | 1.4.7.1.2.2 | FGD - Individual Distribution Schemes/Control Schemes Drawing | 40d | 2022-01-24 | 2022-04-01 | 180SS+10d | 2022-03-07 | 2022-04-08 | 20d | 276.4d |  |  | RPDU5.EG.002 |
| 182 | 1.4.7.1.2.3 | FGD - Grounding Scheme Drawing | 40d | 2022-01-26 | 2022-04-06 | 50FS+10d, 178 | 2022-02-16 | 2022-03-23 | 20d | 271.4d | 40d |  | RPDU5.EG.006 |
| 183 | 1.4.7.1.2.4 | FGD - Electrical Cables List | 40d | 2022-03-16 | 2022-05-25 | 178, 180 | 2022-03-23 | 2022-04-27 | 20d | 241.4d | 0d |  | RPDU5.EM.004 |
| 184 | 1.4.7.1.2.5 | FGD - Cable Trays / Conduits Layout with bill of quantities | 40d | 2022-03-24 | 2022-06-02 | 183SS+5d | 2022-03-31 | 2022-05-05 | 20d | 241.4d |  |  | RPDU5.EV.001 |
| 185 | 1.4.7.1.2.6 | FGD – UPS - Line Diagram | 40d | 2022-04-04 | 2022-06-10 | 180FS+10d | 2022-04-11 | 2022-05-13 | 20d | 236.4d | 0d |  | RPDU5.EG.011 |
| 186 | 1.4.7.1.2.7 | FGD - Illumination Scheme Drawing | 36d | 2022-05-02 | 2022-07-01 | 50, 62 | 2022-03-03 | 2022-04-07 | 20d | 224.4d | 0d |  | RPDU5.EM.003 |
| 187 | 1.4.7.1.2.8 | FGD - Plant lighting Layout Drawing | 36d | 2022-05-02 | 2022-07-01 | 186SS | 2022-03-03 | 2022-04-07 | 20d | 224.4d |  |  | RPDU5.EG.004 |
| 188 | 1.4.7.1.2.9 | FGD - Electrical Equipment Layout | 36d | 2022-05-02 | 2022-07-01 | 50, 62, 178FS+5d | 2022-03-03 | 2022-04-07 | 20d | 224.4d | 0d |  | RPDU5.EG.009 |
| 189 | 1.4.7.1.2.10 | FGD - Electrical / Control Room Layout (Plan and Sections) | 36d | 2022-05-02 | 2022-07-01 | 188SS | 2022-03-03 | 2022-04-07 | 20d | 224.4d |  |  | RPDU5.EG.010 |
| 190 | 1.4.7.1.2.11 | FGD - Lightening Protection Drawing | 40d | 2022-04-06 | 2022-06-15 | 50, 86FS+10d | 2022-04-07 | 2022-05-12 | 20d | 231.4d | 0d |  | RPDU5.EG.007 |
| 191 | 1.4.7.1.2.12 | FGD - Plant Area Grounding and Lightening Protection Layout | 40d | 2022-04-12 | 2022-06-21 | 182SS+3d, 190SS+3d | 2022-04-13 | 2022-05-18 | 20d | 231.4d |  |  | RPDU5.EG.008 |
| 192 | 1.4.7.1.2.13 | FGD & SAC - Auxiliary power calculation for continuous running of FGD plant including SAC at full load. | 32d | 2022-05-09 | 2022-07-01 | 180FS+30d | 2022-05-16 | 2022-07-06 | 30d | 224.4d |  |  | RPDU5.ED.500 |
| 193 | 1.4.7.2 | **SAC** | 122d | 2021-12-01 | 2022-07-01 |  | 2022-01-31 | 2022-06-03 | 72d | 224.4d |  | 0% |  |
| 194 | 1.4.7.2.1 | **SAC - Electrical Load /Drive List** | 20d | 2021-12-01 | 2022-01-05 |  | 2022-01-31 | 2022-03-25 | 32d | 229.4d |  | 0% |  |
| 195 | 1.4.7.2.1.1 | SAC - Electrical Load /Drive List-(First Submission) | 20d | 2021-12-01 | 2022-01-05 | 178SS | 2022-01-31 | 2022-02-09 | 6d | 229.4d | 0d |  |  |
| 196 | 1.4.7.2.2 | **SAC - Electrical Single Line Diagram** | 30d | 2022-01-05 | 2022-02-25 |  | 2022-02-09 | 2022-04-26 | 43d | 256.4d |  | 0% | RPDU5.EG.001 |
| 197 | 1.4.7.2.2.1 | SAC - Electrical Single Line Diagram-(First Submission) | 30d | 2022-01-05 | 2022-02-25 | 195 | 2022-02-09 | 2022-03-25 | 26d | 256.4d | 0d |  |  |
| 198 | 1.4.7.2.3 | SAC- Cable Sizing - Technical Specification | 30d | 2022-01-24 | 2022-03-16 | 197SS+10d | 2022-02-28 | 2022-03-25 | 16d | 281.4d | 0d |  | RPDU5.ED.305 |
| 199 | 1.4.7.2.4 | SAC - Electrical Cable List | 30d | 2022-02-28 | 2022-04-20 | 195, 197 | 2022-03-28 | 2022-04-26 | 17d | 266.4d |  |  | RPDU5.EM.304 |
| 200 | 1.4.7.2.5 | SAC - Cable Trays / Conduits Layout with bill of quantities | 30d | 2022-02-01 | 2022-03-24 | 198SS+5d | 2022-03-08 | 2022-03-29 | 12d | 281.4d |  |  | RPDU5.EV.301 |
| 201 | 1.4.7.2.6 | SAC - Individual Distribution Schemes/Control Schemes Drawing | 30d | 2022-01-24 | 2022-03-16 | 197SS+10d | 2022-02-28 | 2022-03-25 | 16d | 286.4d |  |  | RPDU5.EG.302 |
| 202 | 1.4.7.2.7 | SAC – UPS - Line Diagram | 40d | 2022-02-28 | 2022-05-06 | 197 | 2022-03-28 | 2022-04-26 | 17d | 256.4d |  |  | RPDU5.EG.311 |
| 203 | 1.4.7.2.8 | SAC - Illumination Scheme Drawing | 40d | 2022-01-24 | 2022-04-01 | 54, 68 | 2022-02-14 | 2022-04-13 | 34d | 276.4d | 0d |  | RPDU5.EG.303 |
| 204 | 1.4.7.2.9 | SAC - Plant lighting Layout Drawing | 40d | 2022-01-24 | 2022-04-01 | 203SS | 2022-02-14 | 2022-04-13 | 34d | 276.4d |  |  | RPDU5.EG.304 |
| 205 | 1.4.7.2.10 | SAC - Grounding Scheme Drawing | 40d | 2022-01-06 | 2022-03-17 | 54, 195 | 2022-02-09 | 2022-04-08 | 34d | 282.4d | 27d |  | RPDU5.EG.306 |
| 206 | 1.4.7.2.11 | SAC - Lightening Protection Drawing | 40d | 2022-02-23 | 2022-05-04 | 54, 118FS+16d | 2022-01-31 | 2022-03-11 | 24d | 255.4d | 0d |  | RPDU5.EG.307 |
| 207 | 1.4.7.2.12 | SAC - Plant Area Grounding and Lightening Protection Layout | 40d | 2022-03-01 | 2022-05-10 | 205SS+3d, 206SS+3d | 2022-02-15 | 2022-03-23 | 21d | 255.4d |  |  | RPDU5.EG.308 |
| 208 | 1.4.7.2.13 | SAC - Electrical Equipment Layout | 40d | 2022-01-24 | 2022-04-01 | 54, 68, 195FS+5d | 2022-02-17 | 2022-04-19 | 34d | 224.4d | 0d |  | RPDU5.EG.309 |
| 209 | 1.4.7.2.14 | SAC - Electrical Room Layout (Plan and Sections) | 40d | 2022-04-25 | 2022-07-01 | 208FS+12d | 2022-04-19 | 2022-06-03 | 27d | 224.4d |  |  | RPDU5.EG.310 |

| ID | WBS | Task | Duration | Start | Finish | Predecessors | Baseline start | Baseline finish | Baseline duration | Total slack | Free slack | Planned % Complete | WLG Drg |
| --- | --- | --- | --- | --- | --- | --- | --- | --- | --- | --- | --- | --- | --- |
| 210 | 1.4.8 | **FGD & SAC - Fire Fighting System** | 85d | 2022-02-03 | 2022-07-01 |  | 2022-02-03 | 2022-06-23 | 80d | 224.4d |  | 0% |  |
| 211 | 1.4.8.1 | **FGD & SAC** | 85d | 2022-02-03 | 2022-07-01 |  | 2022-02-03 | 2022-06-23 | 80d | 224.4d |  | 0% |  |
| 212 | 1.4.8.1.1 | FGD & SAC Fire Fighting - Fire Fighting & Detection System Technical Specification | 19d | 2022-02-03 | 2022-03-09 | 50FS+15d | 2022-02-03 | 2022-03-09 | 19d | 290.4d | 0d |  | RPDU5.ED.800 |
| 213 | 1.4.8.1.2 | FGD & SAC Fire Fighting - Hydrants and Water Spray System - Schematic Diagram | 36d | 2022-05-02 | 2022-07-01 | 50FS+50d, 62, 68, 54 | 2022-04-06 | 2022-06-23 | 45d | 224.4d |  |  | RPDU5.ED.830 |
| 214 | 1.4.8.1.3 | FGD & SAC Fire Fighting - Fire Detection Alarm System - Schematic Drawing | 36d | 2022-05-02 | 2022-07-01 | 50FS+30d, 62, 68, 54 | 2022-03-03 | 2022-05-20 | 45d | 224.4d |  |  | RPDU5.ML.803 |
| 215 | 1.4.8.1.4 | FGD & SAC Fire Fighting - Fire Detection Alarm System - Layout drawing | 36d | 2022-05-02 | 2022-07-01 | 50FS+30d, 62, 68, 54 | 2022-03-03 | 2022-05-20 | 45d | 224.4d | 0d |  | RPDU5.ML.832 |
| 216 | 1.4.8.1.5 | FGD & SAC Fire Fighting - Hydrants and Water Spray System - Layout Drawing | 36d | 2022-05-02 | 2022-07-01 | 50FS+30d, 62, 68, 54 | 2022-03-03 | 2022-05-20 | 45d | 224.4d |  |  | RPDU5.ML.800 |
| 217 | 1.4.8.1.6 | FGD & SAC Fire Fighting - Hydrants System - Hydraulic Calculation | 36d | 2022-03-02 | 2022-05-04 | 50FS+30d, 54 | 2022-03-02 | 2022-05-19 | 45d | 258.4d | 34d |  | RPDU5.MA.830 |
| 218 | 1.4.8.1.7 | FGD & SAC Fire Fighting - Water Spray System - Hydraulic Calculation | 36d | 2022-05-02 | 2022-07-01 | 50FS+30d, 62, 68, 54 | 2022-03-03 | 2022-05-20 | 45d | 224.4d | 0d |  | RPDU5.MA.831 |
| 219 | 1.4.8.1.8 | FGD & SAC Fire Fighting - Components Data Sheets | 26d | 2022-05-18 | 2022-07-01 | 217SS+10d, 218SS+10d | 2022-03-22 | 2022-06-08 | 45d | 224.4d |  |  | RPDU5.PA.800 |
| 220 | 1.4.8.1.9 | FGD & SAC Fire Fighting - Fire Detection Alarm System - Data Sheets | 26d | 2022-05-18 | 2022-07-01 | 217SS+10d, 218SS+10d | 2022-03-22 | 2022-06-08 | 45d | 224.4d |  |  | RPDU5.PA.801 |
| 221 | 1.4.8.1.10 | FGD & SAC Fire Fighting - Alarm System at MCC and Control Room - General Arrangement Drawing | 36d | 2022-05-02 | 2022-07-01 | 50, 54, 215SS, 62SS, 68 | 2022-03-03 | 2022-05-20 | 45d | 224.4d |  |  | RPDU5.ML.801 |
| 222 | 2 | **Technical Specification** | 113d | 2021-12-16 | 2022-07-01 |  | 2021-12-20 | 2022-07-05 | 113d | 77d |  | 0% |  |
| 223 | 2.1 | **FGD** | 113d | 2021-12-16 | 2022-07-01 |  | 2021-12-20 | 2022-07-05 | 113d | 77d |  | 0% |  |
| 224 | 2.1.1 | FGD - Booster Fan - Technical Specification | 19d | 2021-12-16 | 2022-01-19 | 26FS+18d, 34 | 2021-12-20 | 2022-01-13 | 15d | 102.4d | 0d |  | RPDU5.PG.030 |
| 225 | 2.1.2 | FGD - LT/HT motors - Technical Specification | 15d | 2022-01-05 | 2022-02-01 | 224SS, 178 | 2022-02-16 | 2022-03-15 | 15d | 311.4d | 0d |  | RPDU5.ED.004 |
| 226 | 2.1.3 | FGD – LT Motors - Technical Specification | 15d | 2022-01-05 | 2022-02-01 | 225SS | 2022-02-16 | 2022-03-15 | 15d | 311.4d | 0d |  | RPDU5.ED.009 |
| 227 | 2.1.4 | FGD – HT Motors - Technical Specification | 15d | 2022-01-05 | 2022-02-01 | 226SS | 2022-02-16 | 2022-03-15 | 15d | 311.4d |  |  | RPDU5.ED.010 |
| 228 | 2.1.5 | FGD - Lifting device for SPC modules maintenance - Technical Specification | 15d | 2021-12-22 | 2022-01-18 | 34, 19 | 2021-12-22 | 2022-01-18 | 15d | 319.4d |  |  | RPDU5.PG.050 |
| 229 | 2.1.6 | FGD - Flue Gas Ducts Expansion Joints - Technical Specification | 15d | 2021-12-16 | 2022-01-12 | 32, 34, 36, 224SS | 2021-12-30 | 2022-01-26 | 15d | 322.4d |  |  | RPDU5.PG.031 / RPDU5.PG.013 |
| 230 | 2.1.7 | FGD - Flue Gas Ducts Dampers - Technical Specification | 15d | 2021-12-16 | 2022-01-12 | 32, 34, 36, 224SS | 2021-12-30 | 2022-01-26 | 15d | 322.4d |  |  | RPDU5.PG.032 |
| 231 | 2.1.8 | FGD - PMCC, MCC, ACDB and DCDB - Technical Specification | 15d | 2022-02-17 | 2022-03-16 | 178FS+25d | 2022-03-31 | 2022-04-27 | 15d | 286.4d |  |  | RPDU5.ED.002 |
| 232 | 2.1.9 | FGD - Electrical Cable Sizing - Technical Specification | 15d | 2022-03-16 | 2022-04-12 | 178, 180 | 2022-03-23 | 2022-04-19 | 15d | 261.4d | 0d |  | RPDU5.ED.005 |
| 233 | 2.1.10 | FGD – LT & HT Switchgears - Technical Specification | 15d | 2022-03-16 | 2022-04-12 | 178, 180 | 2022-03-23 | 2022-04-19 | 15d | 271.4d |  |  | RPDU5.ED.011 |
| 234 | 2.1.11 | FGD – Electrical Panels and Junction Boxes - Technical Specification | 15d | 2022-03-16 | 2022-04-12 | 178, 180 | 2022-03-23 | 2022-04-19 | 15d | 271.4d |  |  | RPDU5.ED.012 |
| 235 | 2.1.12 | FGD – LTMCC / Switchboard - Technical Specification | 15d | 2022-03-16 | 2022-04-12 | 178, 180 | 2022-03-23 | 2022-04-19 | 15d | 271.4d |  |  | RPDU5.ED.013 |
| 236 | 2.1.13 | FGD - MOV - Technical Specification | 15d | 2022-03-16 | 2022-04-12 | 180, 178 | 2022-03-23 | 2022-04-19 | 15d | 271.4d |  |  | RPDU5.ED.003 |
| 237 | 2.1.14 | FGD - Paintings - Technical Specification | 15d | 2022-01-10 | 2022-02-03 | 34, 121SS+5d | 2021-12-23 | 2022-01-19 | 15d | 309.4d | 0d |  | RPDU5.PG.021 |
| 238 | 2.1.15 | FGD - Piping Painting Specification (primer + final at site) | 15d | 2022-01-10 | 2022-02-03 | 237SS | 2021-12-23 | 2022-01-19 | 15d | 309.4d |  |  | RPDU5.PG.011 |
| 239 | 2.1.16 | FGD – UPS - Technical Specification | 15d | 2022-04-20 | 2022-05-17 | 185SS+10d | 2022-04-27 | 2022-05-24 | 15d | 251.4d |  |  | RPDU5.ED.014 |
| 240 | 2.1.17 | FGD & SAC Fire Fighting - Fire Detection Alarm Equipment - Technical Specification | 15d | 2022-02-03 | 2022-03-02 | 212SS | 2022-02-03 | 2022-03-02 | 15d | 294.4d |  |  | RPDU5.PA.802 |
| 241 | 2.1.18 | FGD & SAC Fire Fighting - Fire Extinguishers - Technical Specification | 15d | 2022-02-03 | 2022-03-02 | 212SS | 2022-02-03 | 2022-03-02 | 15d | 294.4d |  |  | RPDU5.PA.803 |
| 242 | 2.1.19 | FGD & SAC Fire Fighting - ERW steel pipes and fittings - Technical Specification | 15d | 2022-02-03 | 2022-03-02 | 212SS | 2022-02-03 | 2022-03-02 | 15d | 294.4d |  |  | RPDU5.PA.804 |
| 243 | 2.1.20 | FGD & SAC Fire Fighting - Pumps - Technical Specification | 15d | 2022-02-03 | 2022-03-02 | 212SS | 2022-02-03 | 2022-03-02 | 15d | 294.4d |  |  | RPDU5.PA.805 |
| 244 | 2.1.21 | FGD & SAC Fire Fighting - Sprinklers - Technical Specification | 15d | 2022-02-03 | 2022-03-02 | 212SS | 2022-02-03 | 2022-03-02 | 15d | 294.4d |  |  | RPDU5.PA.806 |
| 245 | 2.1.22 | FGD – Electrical/Control Cables and Glands - Technical Specification | 15d | 2022-04-04 | 2022-04-28 | 232SS+10d | 2022-04-11 | 2022-05-05 | 15d | 261.4d |  |  | RPDU5.ED.007 |
| 246 | 2.1.23 | FGD - Process Recycle Pumps - Technical Specification | 15d | 2022-01-24 | 2022-02-17 | 36FS+30d, 34, 32 | 2022-02-14 | 2022-03-10 | 15d | 301.4d |  |  | RPDU5.PG.034 |
| 247 | 2.1.24 | FGD - Ash Filters - Technical Specification | 15d | 2022-01-24 | 2022-02-17 | 36FS+30d, 34, 32 | 2022-02-14 | 2022-03-10 | 15d | 301.4d |  |  | RPDU5.PG.035 |
| 248 | 2.1.25 | FGD - Hopper Cleaning Pumps - Technical Specification | 15d | 2022-01-24 | 2022-02-17 | 36FS+30d, 34, 32 | 2022-02-14 | 2022-03-10 | 15d | 301.4d |  |  | RPDU5.PG.036 |
| 249 | 2.1.26 | FGD - Wash Recycle Pumps - Technical Specification | 15d | 2022-01-24 | 2022-02-17 | 36FS+30d, 34, 32 | 2022-02-14 | 2022-03-10 | 15d | 301.4d |  |  | RPDU5.PG.037 |
| 250 | 2.1.27 | FGD - Wash Recycle Ash Filters - Technical Specification | 15d | 2022-01-24 | 2022-02-17 | 36FS+30d, 34, 32 | 2022-02-14 | 2022-03-10 | 15d | 301.4d |  |  | RPDU5.PG.038 |
| 251 | 2.1.28 | FGD - Process Water Pumps - Technical Specification | 15d | 2022-01-24 | 2022-02-17 | 36FS+30d, 34, 32 | 2022-02-14 | 2022-03-10 | 15d | 301.4d |  |  | RPDU5.PG.039 |
| 252 | 2.1.29 | FGD - Acid Transfer Pumps - Technical Specification | 15d | 2022-01-24 | 2022-02-17 | 36FS+30d, 34, 32 | 2022-02-14 | 2022-03-10 | 15d | 301.4d |  |  | RPDU5.PG.040 |
| 253 | 2.1.30 | FGD - FGTR Washing Grid and Nozzles of SPC Modules - Technical Specification | 15d | 2022-01-24 | 2022-02-17 | 36FS+30d, 34, 32 | 2022-02-14 | 2022-03-10 | 15d | 301.4d |  |  | RPDU5.PG.041 |
| 254 | 2.1.31 | FGD - MCU Flue Gas Cooling Grid and Nozzles - Technical Specification | 15d | 2022-01-24 | 2022-02-17 | 36FS+30d, 34, 32 | 2022-02-14 | 2022-03-10 | 15d | 301.4d |  |  | RPDU5.PG.043 |
| 255 | 2.1.32 | FGD - Control Cables Sizing - Technical Specification | 15d | 2022-03-22 | 2022-04-15 | 141, 143 | 2022-03-08 | 2022-04-01 | 15d | 268.4d |  |  | RPDU5.PE.050 |
| 256 | 2.1.33 | FGD - Technical Specification for PLC | 15d | 2022-01-13 | 2022-02-09 | 144SS+15d | 2022-02-14 | 2022-03-10 | 15d | 306.4d |  |  | RPDU5.PE.001 |
| 257 | 2.1.34 | FGD - Heat Insulations - Technical Specification | 15d | 2022-03-10 | 2022-04-06 | 78, 97, 34 | 2022-03-14 | 2022-04-07 | 15d | 274.4d |  |  | RPDU5.PG.022 |
| 258 | 2.1.35 | FGD – Cable Trays - Technical Specification | 15d | 2022-05-12 | 2022-06-08 | 178, 180, 188SS+7d | 2022-03-23 | 2022-04-19 | 15d | 238.4d |  |  | RPDU5.ED.008 |
| 259 | 2.1.36 | FGD - Glass Flake Linings - Technical Specification | 15d | 2022-03-29 | 2022-04-22 | 78, 86FS+5d, 91, 97, 34 | 2022-03-30 | 2022-04-26 | 15d | 264.4d |  |  | RPDU5.PG.020 |

| ID | WBS | Task | Duration | Start | Finish | Predecessors | Baseline start | Baseline finish | Baseline duration | Total slack | Free slack | Calendar | Planned % Complete | WLG Drg |
| --- | --- | --- | --- | --- | --- | --- | --- | --- | --- | --- | --- | --- | --- | --- |
| 260 | 2.1.37 | **FGD - Structural Steel Materials - Technical Specification** | 30d | 2022-03-21 | 2022-05-11 |  | 2022-03-22 | 2022-07-05 | 60d | 254.4d |  |  | 0% | RPDU5.PA.100 |
| 261 | 2.1.37.1 | FGD - Structural Steel Materials - Technical Specification-(First Submission) | 30d | 2022-03-21 | 2022-05-11 | 91, 86, 97, 50, 78 | 2022-03-22 | 2022-05-12 | 30d | 254.4d |  |  |  |  |
| 262 | 2.1.38 | **FGD & SAC - Civil Materials - Technical Specification** | 10d | 2022-05-02 | 2022-05-18 |  | 2022-03-03 | 2022-05-20 | 45d | 0d |  |  | 0% | RPDU5.PA.550/ RPDU5.PA.551 |
| 263 | 2.1.38.1 | FGD & SAC - Civil Materials - Technical Specification-(First Submission) | 10d | 2022-05-02 | 2022-05-18 | 62 | 2022-03-03 | 2022-03-22 | 10d | 0d |  |  |  |  |
| 264 | 2.1.39 | FGD - Junction Boxes - Technical Specification | 20d | 2022-04-04 | 2022-05-06 | 208, 34 | 2022-04-19 | 2022-05-13 | 15d | 256.4d |  |  |  | RPDU5.ED.001 |
| 265 | 2.1.40 | FGD - Grounding and Lightening System - Technical Specification | 20d | 2022-04-19 | 2022-05-24 | 178, 180, 190SS+7d | 2022-04-20 | 2022-05-17 | 15d | 247.4d |  |  |  | RPDU5.ED.006 |
| 266 | 2.1.41 | FGD Electrical Buildings - Lighting - Technical Specification | 26d | 2022-05-18 | 2022-07-01 | 62FS+10d | 2022-05-12 | 2022-06-08 | 15d | 224.4d |  |  |  | RPDU5.PG.502 |
| 267 | 2.1.42 | FGD Electrical Buildings - Earthing Material and Lightning Arrestor - Technical Specification | 26d | 2022-05-18 | 2022-07-01 | 62FS+10d | 2022-05-12 | 2022-06-08 | 15d | 224.4d |  |  |  | RPDU5.PG.503 |
| 268 | 2.1.43 | FGD Electrical Buildings - HVAC/AC - Technical Specification | 26d | 2022-05-18 | 2022-07-01 | 62FS+10d | 2022-05-12 | 2022-06-08 | 15d | 224.4d |  |  |  | RPDU5.PG.501 |
| 269 | 2.2 | **SAC** | 113d | 2021-12-16 | 2022-07-01 |  | 2022-01-03 | 2022-05-27 | 84d | 224.4d |  |  | 0% |  |
| 270 | 2.2.1 | SAC - Lifting device for SAC equipment maintenance - Technical Specification | 15d | 2021-12-16 | 2022-01-12 | 45FS+9d | 2022-03-10 | 2022-04-06 | 15d | 322.4d |  |  |  | RPDU5.PG.350 |
| 271 | 2.2.2 | SAC - Paintings - Technical Specification | 15d | 2021-12-16 | 2022-01-12 | 45FS+9d | 2022-03-10 | 2022-04-06 | 15d | 322.4d |  |  |  | RPDU5.PG.321 |
| 272 | 2.2.3 | **SAC - Structural Steel Materials - Technical Specification** | 30d | 2022-01-26 | 2022-03-18 |  | 2022-01-03 | 2022-02-23 | 30d | 284.4d |  |  | 0% | RPDU5.PA.300 |
| 273 | 2.2.3.1 | SAC - Structural Steel Materials - Technical Specification-(First Submission) | 30d | 2022-01-26 | 2022-03-18 | 118 | 2022-01-03 | 2022-01-27 | 15d | 284.4d |  |  |  |  |
| 274 | 2.2.4 | SAC - Vapour-Liquid Separator - Technical Specification | 50d | 2022-01-24 | 2022-04-20 | 45FS+30d, 43, 41 | 2022-05-03 | 2022-05-27 | 15d | 266.4d |  |  |  | RPDU5.PG.330 |
| 275 | 2.2.5 | SAC - Reboiler Heater Exchanger - Technical Specification | 50d | 2022-01-24 | 2022-04-20 | 43, 45FS+30d, 41 | 2022-05-03 | 2022-05-27 | 15d | 266.4d |  |  |  | RPDU5.PG.331 |
| 276 | 2.2.6 | SAC - Acid Condenser - Technical Specification | 50d | 2022-01-24 | 2022-04-20 | 43, 45FS+30d, 41 | 2022-05-03 | 2022-05-27 | 15d | 266.4d |  |  |  | RPDU5.PG.332 |
| 277 | 2.2.7 | SAC - Circulation Pumps - Technical Specification | 50d | 2022-01-24 | 2022-04-20 | 43, 45FS+30d, 41 | 2022-05-03 | 2022-05-27 | 15d | 266.4d |  |  |  | RPDU5.PG.333 |
| 278 | 2.2.8 | SAC - Vacuum System - Technical Specification | 50d | 2022-01-24 | 2022-04-20 | 43, 45FS+30d, 41 | 2022-05-03 | 2022-05-27 | 15d | 266.4d |  |  |  | RPDU5.PG.334 |
| 279 | 2.2.9 | SAC Buildings - HVAC/AC - Technical Specification | 52d | 2022-04-04 | 2022-07-01 | 68FS+40d | 2022-04-25 | 2022-05-19 | 15d | 224.4d |  |  |  | RPDU5.PG.551 |
| 280 | 2.2.10 | SAC Buildings - Lighting - Technical Specification | 52d | 2022-04-04 | 2022-07-01 | 68FS+40d | 2022-04-25 | 2022-05-19 | 15d | 224.4d |  |  |  | RPDU5.PG.552 |
| 281 | 2.2.11 | SAC Buildings - Earthing Material and Lightning Arrestor - Technical Specification | 52d | 2022-04-04 | 2022-07-01 | 68FS+40d | 2022-04-25 | 2022-05-19 | 15d | 224.4d |  |  |  | RPDU5.PG.553 |
| 282 | 3 | Review of Vendor Technical offer | 80d | 2022-02-15 | 2022-07-05 | 224FS+15d | 2022-02-09 | 2022-07-27 | 96d | 102.4d | 0d |  |  |  |
| 283 | 4 | Placement or Orders/Purchase orders | 100d | 2022-03-22 | 2022-07-16 | 282SS+30d | 2022-03-16 | 2022-09-06 | 149d | 153d | 0d | RNSG 6 days *10 |  |  |

| ID | WBS | Task | Duration | Start | Finish | Predecessors | Baseline start | Baseline finish | Baseline duration | Total slack | Free slack | Calendar | Planned % Complete |
| --- | --- | --- | --- | --- | --- | --- | --- | --- | --- | --- | --- | --- | --- |
| 284 | 5 | **Delivery to Site (Onshore & Offshore)** | 374.8d | 2022-03-22 | 2023-06-01 |  | 2022-06-15 | 2023-06-12 | 309.6d | 50.4d |  | RNSG 6 days *10 | 0% |
| 285 | 5.1 | Onshore Delivery at Site | 181d | 2022-03-22 | 2023-02-01 | 283SS | 2022-07-11 | 2023-06-12 | 8mo | 102.4d |  |  |  |
| 286 | 5.2 | **WLG USA Catalyst Delivery** | 80d | 2023-03-01 | 2023-06-01 |  | 2022-06-15 | 2023-03-21 | 238.7d | 50.4d |  | RNSG 6 days *10 | 0% |
| 287 | 5.2.1 | Gore SPC Module Ex works & FOB USA | 28d | 2023-03-01 | 2023-04-01 | 10FS+416d | 2022-06-15 | 2022-11-30 | 4mo | 50.4d | 0d | RNSG 6 days *10 |  |
| 288 | 5.2.2 | Shipment of Catalyst | 25d | 2023-04-03 | 2023-05-01 | 287 | 2022-12-27 | 2023-02-07 | 1mo | 50.4d | 0d | RNSG 6 days *10 |  |
| 289 | 5.2.3 | Custom Clearance & Delivery at Site | 27d | 2023-05-02 | 2023-06-01 | 288 | 2023-02-07 | 2023-03-21 | 1mo | 50.4d |  | RNSG 6 days *10 |  |
| 290 | 6 | **Erection Schedule** | 257d | 2022-06-01 | 2023-03-28 |  | 2022-06-24 | 2023-08-31 | 371d | 0d |  | RNSG 6 days *10 | 0% |
| 291 | 6.1 | Civil | 99d | 2022-06-01 | 2022-09-24 | 64, 262FS+12d | 2022-06-24 | 2022-10-17 | 98d | 0d |  | RNSG 6 days *10 |  |
| 292 | 6.2 | Mechanical | 160d | 2022-09-01 | 2023-03-07 | 291SS+79d | 2022-09-26 | 2023-04-05 | 164d | 0d |  | RNSG 6 days *10 |  |
| 293 | 6.3 | Electrical | 100d | 2022-12-01 | 2023-03-28 | 292SS+78d | 2022-12-28 | 2023-05-19 | 122d | 0d |  | RNSG 6 days *10 |  |
| 294 | 6.4 | C&I | 100d | 2022-12-01 | 2023-03-28 | 293SS | 2022-12-28 | 2023-05-19 | 122d | 0d |  | RNSG 6 days *10 |  |
| 295 | 7 | Tie in | 20d | 2023-03-28 | 2023-04-20 | 292, 294 | 2023-04-05 | 2023-05-05 | 26d | 0d |  | RNSG 6 days *10 |  |
| 296 | 8 | Commissioning of Plant | 60d | 2023-04-20 | 2023-06-29 | 295 | 2023-05-05 | 2023-07-26 | 70d | 0d |  | RNSG 6 days *10 |  |
| 297 | 9 | PG TEST | 27d | 2023-06-29 | 2023-07-31 | 296 | 2023-07-26 | 2023-08-31 | 31d | 0d |  | RNSG 6 days *10 |  |
